# 施工进度计划

Schedule from MS Project, 2024-07-10 to 2025-02-23.
鏂戦┈杩涘害

## Calendars

- 标准: Mon-Sun 08:00-12:00, 13:00-17:00.

## Schedule

| ID | WBS | Task | Duration | Start | Finish | Predecessors | Total slack | Free slack |
| --- | --- | --- | --- | --- | --- | --- | --- | --- |
| 1 | 1 | **施工进度计划** | 229d | 2024-07-10 | 2025-02-23 |  | 0d |  |
| 2 | 1.1 | **土建施工** | 114d | 2024-07-10 | 2024-10-31 |  | 0d |  |
| 3 | 1.1.1 | 基础施工 | 30d | 2024-07-10 | 2024-08-08 |  | 0d |  |
| 4 | 1.1.2 | 一层土建施工 | 18d | 2024-08-09 | 2024-08-26 | 3 | 0d |  |
| 5 | 1.1.3 | 二层土建施工 | 15d | 2024-08-27 | 2024-09-10 | 4 | 0d |  |
| 6 | 1.1.4 | 三层土建施工 | 15d | 2024-09-11 | 2024-09-25 | 5 | 0d |  |
| 7 | 1.1.5 | 四层土建施工 | 13d | 2024-09-26 | 2024-10-08 | 6 | 0d |  |
| 8 | 1.1.6 | 五层土建施工 | 13d | 2024-10-09 | 2024-10-21 | 7 | 0d |  |
| 9 | 1.1.7 | 屋面土建施工 | 10d | 2024-10-22 | 2024-10-31 | 8 | 115d |  |
| 10 | 1.2 | **幕墙施工** | 55d | 2024-10-09 | 2024-12-02 |  | 83d |  |
| 11 | 1.2.1 | 北立面幕墙施工 | 30d | 2024-10-09 | 2024-11-07 | 7 | 83d | 0d |
| 12 | 1.2.2 | 南立面幕墙施工 | 25d | 2024-11-08 | 2024-12-02 | 11 | 83d |  |
| 13 | 1.3 | **机电施工** | 125d | 2024-10-22 | 2025-02-23 |  | 0d |  |
| 14 | 1.3.1 | 一层机电施工 | 25d | 2024-10-22 | 2024-11-15 | 8 | 0d |  |
| 15 | 1.3.2 | 二层机电施工 | 20d | 2024-11-16 | 2024-12-05 | 14 | 0d |  |
| 16 | 1.3.3 | 三层机电施工 | 20d | 2024-12-06 | 2024-12-25 | 15 | 0d |  |
| 17 | 1.3.4 | 四层机电施工 | 20d | 2024-12-26 | 2025-01-14 | 16 | 0d |  |
| 18 | 1.3.5 | 五层机电施工 | 20d | 2025-01-15 | 2025-02-03 | 17 | 0d |  |
| 19 | 1.3.6 | 屋面机电施工 | 20d | 2025-02-04 | 2025-02-23 | 18 | 0d |  |
